# Cas TNP

Schedule from MS Project, 2014-05-19 to 2015-03-27, costs in €, A marks actual dates.

## Calendars

- Standard: Mon-Fri 08:00-12:00, 13:00-17:00; Sat-Sun off.

## Resources

| Resource | Group | Rate | Cost per use |
| --- | --- | --- | --- |
| ING DI | TERTEL | 150 |  |
| TEC DI | TERTEL | 80 |  |
| Sous-traitant n°1 | PRINT SYSTEM |  | 1500 |
| Sous-traitant n°2 | PRINT SYSTEM |  | 50000 |
| Sous-traitant n°3 | PRINT SYSTEM |  | 30000 |
| Sous-traitant n°4 | PRINT SYSTEM |  | 40000 |
| TEC DE | TERTEL | 60 |  |
| ING DE | TERTEL | 90 |  |

## Schedule

| ID | WBS | Task | Type | Duration | Start | Finish | Predecessors | Complete | Remaining | Baseline start | Baseline finish | Baseline duration | Total slack | Free slack | Resources | Work | Actual work | Cost | Baseline cost | Actual cost |
| --- | --- | --- | --- | --- | --- | --- | --- | --- | --- | --- | --- | --- | --- | --- | --- | --- | --- | --- | --- | --- |
| 1 | 1 | **Projet TNP** |  | 225d | 2014-05-19 A | 2015-03-27 |  | 24% | 170.09d | 2014-05-19 | 2015-03-27 | 225d | 0d |  |  | 6390h | 1700h | 698,700.12 | 643,900 | 214,400.12 |
| 2 | Jalon 1 | Début du projet | milestone | 0d | 2014-05-19 | 2014-05-19 |  |  |  | 2014-05-19 | 2014-05-19 | 0d | 0d |  |  |  |  |  |  |  |
| 3 | 1.1 | Combiné |  | 30d | 2015-01-12 | 2015-02-20 | 6 |  |  | 2015-01-12 | 2015-02-20 | 30d | 0d |  | Sous-traitant n°2 | 240h |  | 50,000 | 50,000 |  |
| 4 | Jalon 7 | Fin du Combiné | milestone | 0d | 2015-02-20 | 2015-02-20 | 3 |  |  | 2015-02-20 | 2015-02-20 | 0d | 0d |  |  |  |  |  |  |  |
| 5 | 1.2 | Alimentation |  | 20d | 2014-12-15 | 2015-01-09 | 12, 16 |  |  | 2014-12-15 | 2015-01-09 | 20d | 0d |  | Sous-traitant n°3 | 160h |  | 30,000 | 30,000 |  |
| 6 | Jalon 6 | Fin d'Alimentation | milestone | 0d | 2015-01-09 | 2015-01-09 | 5 |  |  | 2015-01-09 | 2015-01-09 | 0d | 0d |  |  |  |  |  |  |  |
| 7 | 1.3 | **Electronique** |  | 130d | 2014-06-16 | 2014-12-12 |  |  |  | 2014-06-16 | 2014-12-12 | 130d | 0d |  |  | 2470h |  | 211,000 | 211,000 |  |
| 8 | 1.3.1 | Analyseur Synthétiseur |  | 50d | 2014-06-16 | 2014-08-22 | 36 |  |  | 2014-06-16 | 2014-08-22 | 50d | 0d |  | ING DE [125%]; TEC DE [75%] | 800h |  | 63,000 | 63,000 |  |
| 9 | Jalon 3 | Fin de l'analyseur synthétiseur | milestone | 0d | 2014-08-22 | 2014-08-22 | 8 |  |  | 2014-08-22 | 2014-08-22 | 0d | 0d |  |  |  |  |  |  |  |
| 10 | 1.3.2 | Antenne |  | 30d | 2014-10-20 | 2014-11-28 | 14 |  |  | 2014-10-20 | 2014-11-28 | 30d | 60d |  | ING DE [83.3%]; TEC DE [41.7%] | 300h |  | 24,000 | 24,000 |  |
| 11 | 1.3.3 | Amplificateur de puissance |  | 40d | 2014-10-20 | 2014-12-12 | 14 |  |  | 2014-10-20 | 2014-12-12 | 40d | 0d |  | Sous-traitant n°4 | 320h |  | 40,000 | 40,000 |  |
| 12 | Jalon 5 | Fin d'Amplificateur de puissance | milestone | 0d | 2014-12-12 | 2014-12-12 | 11 |  |  | 2014-12-12 | 2014-12-12 | 0d | 0d |  |  |  |  |  |  |  |
| 13 | 1.3.4 | Emetteur - Recepteur |  | 40d | 2014-08-25 | 2014-10-17 | 9 |  |  | 2014-08-25 | 2014-10-17 | 40d | 0d |  | ING DE [93.8%]; TEC DE [46.9%] | 450h |  | 36,000 | 36,000 |  |
| 14 | Jalon 4 | Fin Emetteur - Recepteur | milestone | 0d | 2014-10-17 | 2014-10-17 | 13 |  |  | 2014-10-17 | 2014-10-17 | 0d | 0d |  |  |  |  |  |  |  |
| 15 | 1.3.5 | Codeur - Décodeur |  | 30d | 2014-06-16 | 2014-07-25 | 36 |  |  | 2014-06-16 | 2014-07-25 | 30d | 70d | 0d | ING DE [83.3%]; TEC DE [41.7%] | 300h |  | 24,000 | 24,000 |  |
| 16 | 1.3.6 | Modulateur - Démodulateur |  | 30d | 2014-07-28 | 2014-09-05 | 15 |  |  | 2014-07-28 | 2014-09-05 | 30d | 70d |  | ING DE [83.3%]; TEC DE [41.7%] | 300h |  | 24,000 | 24,000 |  |
| 17 | 1.4 | **Logiciel LOGIC** |  | 120d | 2014-05-19 A | 2014-10-31 |  | 63% | 44.8d | 2014-05-19 | 2014-10-26 | 95d | 80d |  |  | 2620h | 1700h | 314,700.12 | 259,900 | 214,400.12 |
| 18 | 1.4.A | Réaliser les spécifications et la conception générale du logiciel |  | 40.91d | 2014-05-19 A | 2014-07-14 A | 36 | 100% |  | 2014-05-19 | 2014-06-27 | 30d |  |  | ING DI [1100.1%]; TEC DI [550.1%] | 960h | 960h | 121,600.12 | 91,200 | 121,600.12 |
| 19 | 1.4.B | Tester le fonctionnement de l'ensemble des modules |  | 20d | 2014-10-06 | 2014-10-31 | 26, 30 |  |  | 2014-09-01 | 2014-09-26 | 20d | 80d | 0d | ING DI [50%]; TEC DI | 240h |  | 24,800 | 24,800 |  |
| 20 | 1.4.1 | **Module N°1** |  | 40d | 2014-07-14 A | 2014-09-05 A |  | 100% |  | 2014-06-30 | 2014-07-18 | 15d |  |  |  | 160h | 160h | 24,000 | 18,000 | 24,000 |
| 21 | 1.4.1.A | Coder, tester et intégrer le Module 1 |  | 40d | 2014-07-14 A | 2014-09-05 A | 18 | 100% |  | 2014-06-30 | 2014-07-18 | 15d |  |  | ING DI [50%] | 160h | 160h | 24,000 | 18,000 | 24,000 |
| 22 | Jalon 2 | Fin du Module N°1 | milestone | 0d | 2014-08-08 A | 2014-08-08 A | 21 | 100% |  | 2014-07-18 | 2014-07-18 | 0d |  |  |  |  |  |  |  |  |
| 23 | 1.4.2 | **Module N°2** |  | 10d | 2014-07-14 A | 2014-07-25 A |  | 100% |  | 2014-06-30 | 2014-07-11 | 10d |  |  |  | 40h | 40h | 6,000 | 6,000 | 6,000 |
| 24 | 1.4.2.A | Coder, tester et intégrer le Module 2 |  | 10d | 2014-07-14 A | 2014-07-25 A | 18 | 100% |  | 2014-06-30 | 2014-07-11 | 10d |  |  | ING DI [50%] | 40h | 40h | 6,000 | 6,000 | 6,000 |

| ID | WBS | Task | Type | Duration | Start | Finish | Predecessors | Complete | Remaining | Baseline start | Baseline finish | Baseline duration | Total slack | Free slack | Resources | Work | Actual work | Cost | Baseline cost | Actual cost |
| --- | --- | --- | --- | --- | --- | --- | --- | --- | --- | --- | --- | --- | --- | --- | --- | --- | --- | --- | --- | --- |
| 25 | 1.4.3 | **Module N°3** |  | 15d | 2014-07-28 A | 2014-08-15 A |  | 100% |  | 2014-07-14 | 2014-08-01 | 15d |  |  |  | 300h | 300h | 32,400 | 32,400 | 32,400 |
| 26 | 1.4.3.A | Coder, tester et intégrer le Module 3 |  | 15d | 2014-07-28 A | 2014-08-15 A | 24 | 100% |  | 2014-07-14 | 2014-08-01 | 15d |  |  | ING DI; TEC DI [150%] | 300h | 300h | 32,400 | 32,400 | 32,400 |
| 27 | 1.4.4 | **Module N°4** |  | 20d | 2014-08-11 A | 2014-09-05 |  | 50% | 10d | 2014-07-21 | 2014-08-01 | 10d | 80d |  |  | 320h | 160h | 36,800 | 18,400 | 18,400 |
| 28 | 1.4.4.A | Coder, tester et intégrer le Module 4 |  | 20d | 2014-08-11 A | 2014-09-05 | 22 | 50% | 10d | 2014-07-21 | 2014-08-01 | 10d | 80d | 0d | ING DI; TEC DI | 320h | 160h | 36,800 | 18,400 | 18,400 |
| 29 | 1.4.5 | **Module N°5** |  | 20d | 2014-09-08 | 2014-10-03 |  |  |  | 2014-08-04 | 2014-08-29 | 20d | 80d |  |  | 320h |  | 25,600 | 25,600 |  |
| 30 | 1.4.5.A | Coder, tester et intégrer le Module 5 |  | 20d | 2014-09-08 | 2014-10-03 | 28 |  |  | 2014-08-04 | 2014-08-29 | 20d | 80d | 0d | TEC DI [200%] | 320h |  | 25,600 | 25,600 |  |
| 31 | 1.4.6 | **Doc technique et mode d'emploi** |  | 35d | 2014-08-11 A | 2014-09-26 |  | 29% | 25d | 2014-08-15 | 2014-09-05 | 35d | 105d |  |  | 280h | 80h | 42,000 | 43,500 | 12,000 |
| 32 | 1.4.6.A | Rédiger la documentation technique et le mode d'emploi et les faire imprimer |  | 35d | 2014-08-11 A | 2014-09-26 | 22 | 29% | 25d | 2014-07-21 | 2014-09-05 | 35d | 105d | 25d | ING DI; Sous-traitant n°1 | 280h | 80h | 42,000 | 43,500 | 12,000 |
| 33 | Jalon 8 | Fin du logiciel LOGIC | milestone | 0d | 2014-10-31 | 2014-10-31 | 32, 19 |  |  | 2014-09-26 | 2014-09-26 | 0d | 80d |  |  |  |  | 1,500 |  |  |
| 34 | 1.5 | **Dossiers** |  | 225d | 2014-05-19 | 2015-03-27 |  |  |  | 2014-05-19 | 2015-03-27 | 225d | 0d |  |  | 900h |  | 93,000 | 93,000 |  |
| 35 | 1.5.1 | Dossier des spécifications |  | 20d | 2014-05-19 | 2014-06-13 | 2 |  |  | 2014-05-19 | 2014-06-13 | 20d | 0d |  | ING DI [62.5%]; TEC DI [31.2%]; ING DE [62.5%]; TEC DE [31.2%] | 300h |  | 31,000 | 31,000 |  |
| 36 | Jalon 2 | Fin du dossier de spécifications du TNP | milestone | 0d | 2014-06-13 | 2014-06-13 | 35 |  |  | 2014-06-13 | 2014-06-13 | 0d | 0d |  |  |  |  |  |  |  |
| 37 | 1.5.2 | Rapport sur les tests d'ensemble |  | 25d | 2015-02-23 | 2015-03-27 | 4, 10, 33 |  |  | 2015-02-23 | 2015-03-27 | 25d | 0d |  | ING DI; TEC DI [50%]; ING DE; TEC DE [50%] | 600h |  | 62,000 | 62,000 |  |
| 38 | Jalon 3 | Fin du projet | milestone | 0d | 2015-03-27 | 2015-03-27 | 37 |  |  | 2015-03-27 | 2015-03-27 | 0d | 0d |  |  |  |  |  |  |  |
